# Reunion de Accionistas

Schedule from MS Project, 2015-03-03 to 2015-03-24.
Informe Anual de 2009

## Calendars

- Estándar: Mon-Fri 09:00-13:00, 15:00-19:00; Sat-Sun off.

## Schedule

| ID | WBS | Task | Type | Duration | Start | Finish | Predecessors | Total slack | Free slack |
| --- | --- | --- | --- | --- | --- | --- | --- | --- | --- |
| 1 | 1 | **Reunión de Accionistas** |  | 15.5d | 2015-03-03 | 2015-03-24 |  | 0d |  |
| 2 | 1.1 | **Planificación preliminar** |  | 5.5d | 2015-03-03 | 2015-03-10 |  | 0d |  |
| 3 | 1.1.1 | Programar fecha de la conferencia |  | 2d | 2015-03-03 | 2015-03-04 |  | 0d |  |
| 4 | 1.1.2 | Reservar centro de conferencias |  | 1d | 2015-03-05 | 2015-03-05 | 3 | 0d |  |
| 5 | 1.1.3 | Buscar Conferenciante |  | 3d | 2015-03-05 | 2015-03-10 | 4FS-0.5d | 0d |  |
| 6 | 1.1.4 | Planificación preliminar completa | milestone | 0d | 2015-03-10 | 2015-03-10 | 5 | 0d |  |
| 7 | 1.2 | **Carta de notificación** |  | 5d | 2015-03-10 | 2015-03-17 | 2 | 5d |  |
| 8 | 1.2.1 | Ordenar lista de envío |  | 1h | 2015-03-10 | 2015-03-10 |  | 5d | 0d |
| 9 | 1.2.2 | Preparar carta |  | 1d | 2015-03-10 | 2015-03-11 | 8SS | 5d | 0d |
| 10 | 1.2.3 | Revisar carta |  | 1d | 2015-03-11 | 2015-03-12 | 9 | 5d | 0d |
| 11 | 1.2.4 | Aprobar carta |  | 1d | 2015-03-12 | 2015-03-13 | 10 | 5d | 0d |
| 12 | 1.2.5 | Imprimir carta |  | 2d | 2015-03-13 | 2015-03-17 | 11 | 5d | 0d |
| 13 | 1.2.6 | Enviar carta | milestone | 0d | 2015-03-17 | 2015-03-17 | 12 | 5d |  |
| 14 | 1.3 | **Detalles de la reunión** |  | 8d | 2015-03-10 | 2015-03-20 | 2 | 0d |  |
| 15 | 1.3.1 | Preparar menú con empresa catering |  | 3d | 2015-03-10 | 2015-03-13 |  | 0d |  |
| 16 | 1.3.2 | Preparar salas de reunión del comité |  | 1d | 2015-03-13 | 2015-03-16 | 15 | 0d |  |
| 17 | 1.3.3 | Preparar equipamiento necesario |  | 2d | 2015-03-12 | 2015-03-16 | 16FF | 0d |  |
| 18 | 1.3.4 | Preparar programa |  | 3d | 2015-03-16 | 2015-03-19 | 17 | 0d |  |
| 19 | 1.3.5 | Imprimir programa |  | 1d | 2015-03-19 | 2015-03-20 | 18 | 0d |  |
| 20 | 1.4 | Celebración de la reunión | milestone | 0d | 2015-03-24 | 2015-03-24 | 14FS+2d | 0d |  |
