# Reunion de Accionistas

Schedule from MS Project, 2015-03-03 to 2015-03-27, costs in €.
Informe Anual de 2009

## Calendars

- Estándar: Mon-Fri 09:00-13:00, 15:00-19:00; Sat-Sun off. Exceptions (off unless hours are given): 2015-03-03 09:00-13:00, 15:00-16:00 (Cena de empresa), 2015-03-16 (Festivo).

## Resources

| Resource | Group | Rate |
| --- | --- | --- |
| Secretario | Personal oficina | 10 |
| Vicepresidente | Directiva | 40.87 |
| Jefe oficina | Directiva | 21.63 |
| Auxiliar administrativo | Personal oficina | 20 |

## Schedule

| ID | WBS | Task | Type | Duration | Start | Finish | Predecessors | Total slack | Free slack | Resources | Work | Cost |
| --- | --- | --- | --- | --- | --- | --- | --- | --- | --- | --- | --- | --- |
| 1 | 1 | **Reunión de Accionistas** |  | 16.75d | 2015-03-03 | 2015-03-27 |  | 0d |  |  | 121h | 2,726.23 |
| 2 | 1.1 | **Planificación preliminar** |  | 6.25d | 2015-03-03 | 2015-03-11 |  | 0d |  |  | 48h | 1,099.23 |
| 3 | 1.1.1 | Programar fecha de la conferencia |  | 1d | 2015-03-03 | 2015-03-04 |  | 0.12d | 0d | Vicepresidente; Jefe oficina | 16h | 500 |
| 4 | 1.1.2 | Reservar centro de conferencias |  | 1d | 2015-03-04 | 2015-03-05 | 3 | 0.12d |  | Secretario | 8h | 80 |
| 5 | 1.1.3 | Buscar Conferenciante |  | 3d | 2015-03-05 | 2015-03-11 | 4FS-0.5d | 0d |  | Jefe oficina | 24h | 519.23 |
| 6 | 1.1.4 | Planificación preliminar completa | milestone | 0d | 2015-03-11 | 2015-03-11 | 5 | 0d |  |  |  |  |
| 7 | 1.2 | **Carta de notificación** |  | 5.38d | 2015-03-11 | 2015-03-19 | 2 | 4.38d |  |  | 25h | 675 |
| 8 | 1.2.1 | Ordenar lista de envío |  | 1h | 2015-03-11 | 2015-03-11 |  | 4.25d | 0d | Secretario | 1h | 15 |
| 9 | 1.2.2 | Preparar carta |  | 1d | 2015-03-11 | 2015-03-12 | 8SS | 4.38d | 0.31d | Auxiliar administrativo | 8h | 160 |
| 10 | 1.2.3 | Revisar carta |  | 1d | 2015-03-13 | 2015-03-16 | 9 | 4.12d | 0d | Jefe oficina | 8h | 173.08 |
| 11 | 1.2.4 | Aprobar carta |  | 1d | 2015-03-17 | 2015-03-18 | 10 | 5d | 0d | Vicepresidente | 8h | 326.92 |
| 12 | 1.2.5 | Imprimir carta |  | 2d | 2015-03-18 | 2015-03-19 | 11 | 5.12d | 0d |  |  |  |
| 13 | 1.2.6 | Enviar carta | milestone | 0d | 2015-03-19 | 2015-03-19 | 12 | 5.12d |  |  |  |  |
| 14 | 1.3 | **Detalles de la reunión** |  | 8.5d | 2015-03-11 | 2015-03-25 | 2 | 0d |  |  | 48h | 952 |
| 15 | 1.3.1 | Preparar menú con empresa catering |  | 3d | 2015-03-11 | 2015-03-18 |  | 0d |  | Auxiliar administrativo | 24h | 480 |
| 16 | 1.3.2 | Preparar salas de reunión del comité |  | 1d | 2015-03-18 | 2015-03-19 | 15 | 0d |  | Secretario | 8h | 88 |
| 17 | 1.3.3 | Preparar equipamiento necesario |  | 2d | 2015-03-17 | 2015-03-19 | 16FF | 0d |  | Auxiliar administrativo | 16h | 384 |
| 18 | 1.3.4 | Preparar programa |  | 3d | 2015-03-19 | 2015-03-24 | 17 | 0d |  |  |  |  |
| 19 | 1.3.5 | Imprimir programa |  | 1d | 2015-03-24 | 2015-03-25 | 18 | 0d |  |  |  |  |
| 20 | 1.4 | Celebración de la reunión | milestone | 0d | 2015-03-27 | 2015-03-27 | 14FS+2d | 0d |  |  |  |  |
