# Proyecto de las oficinas centrales

Schedule from MS Project, 2015-03-09 to 2015-07-01, costs in $.
Reubicación

## Calendars

- Estándar: Mon-Fri 08:00-12:00, 13:00-17:00; Sat-Sun off.

## Resources

| Resource | Group | Rate |
| --- | --- | --- |
| auxiliar administrativo | personal oficina | 20 |
| arquitecto | contratado | 65 |
| ayudante del jefe de operaciones | personal oficina | 25 |
| carpintero | mantenimiento | 35 |
| responsable de finanzas | directiva | 38.46 |
| técnico informático 1 | técnicos | 33 |
| técnico informático 2 | técnicos | 26 |
| sala de conferencias | espacios |  |
| empresa de demolición | contratado |  |
| electricista | mantenimiento | 50 |
| empresa revestimiento suelo | contratado |  |
| empresa constructora | contratado | 50 |
| portero | mantenimiento | 16 |
| ordenanza | mantenimiento | 18 |
| jefe de oficina | directiva | 21.63 |
| jefe de operaciones | directiva | 25 |
| pintor | mantenimiento | 40 |
| presidente | directiva | 43.27 |
| agente inmobiliario | contratado | 50 |
| camión | contratado | 30 |
| vicepresidente | directiva | 36.06 |
| servidor |  |  |

## Schedule

| ID | WBS | Task | Type | Duration | Start | Finish | Predecessors | Total slack | Free slack | Resources | Work | Cost |
| --- | --- | --- | --- | --- | --- | --- | --- | --- | --- | --- | --- | --- |
| 1 | 1 | **Reubicación oficinas centrales** |  | 82.38d | 2015-03-09 | 2015-07-01 |  | 0d |  |  | 1235h | 51,934.38 |
| 2 | 1.1 | **Planificación** |  | 35d | 2015-03-09 | 2015-04-24 |  | 0.75d | 0d |  | 676h | 29,030.38 |
| 3 | 1.1.1 | Escribir propuesta |  | 3d | 2015-03-09 | 2015-03-11 |  | 0.75d | 0d | jefe de operaciones; jefe de oficina | 48h | 1,119.23 |
| 4 | 1.1.2 | Contratar arquitecto |  | 2d | 2015-03-10 | 2015-03-11 | 3FF | 0.75d | 0d | jefe de oficina; vicepresidente | 32h | 923.07 |
| 5 | 1.1.3 | Localizar nueva ubicación |  | 1w | 2015-03-12 | 2015-03-18 | 4 | 0.75d | 0d | arquitecto; jefe de oficina; agente inmobiliario | 120h | 5,465.38 |
| 6 | 1.1.4 | Presentar propuesta |  | 2d | 2015-03-19 | 2015-03-20 | 5 | 0.75d | 0d | jefe de operaciones; sala de conferencias; arquitecto | 48h | 1,440 |
| 7 | 1.1.5 | Aprobación de la directiva | milestone | 0d | 2015-03-20 | 2015-03-20 | 6 | 0.75d | 0d |  |  |  |
| 8 | 1.1.6 | Negociar nuevo alquiler |  | 4d | 2015-03-23 | 2015-03-26 | 7 | 0.75d | 0d | vicepresidente; responsable de finanzas; agente inmobiliario | 96h | 3,984.62 |
| 9 | 1.1.7 | Terminar dibujos |  | 2w | 2015-03-25 | 2015-04-07 | 8FS-2d | 0.75d | 0d | arquitecto | 80h | 5,200 |
| 10 | 1.1.8 | Seleccionar subcontratados |  | 1.5w | 2015-04-06 | 2015-04-15 | 9FS-2d | 0.75d | 0d | arquitecto; jefe de operaciones; jefe de oficina | 180h | 6,698.08 |
| 11 | 1.1.9 | Contratar empresa de mudanzas |  | 3d | 2015-04-10 | 2015-04-15 | 10FF | 0.75d | 0d | jefe de operaciones [50%] | 12h | 300 |
| 12 | 1.1.10 | Enviar dibujos |  | 1.5w | 2015-04-15 | 2015-04-24 | 11 | 0.75d | 0d | arquitecto | 60h | 3,900 |
| 13 | 1.1.11 | Permisos recibidos | milestone | 0d | 2015-04-24 | 2015-04-24 | 12 | 0.75d |  |  |  |  |
| 14 | 1.2 | **Remodelación** |  | 38d | 2015-04-27 | 2015-06-17 | 2 | 0d |  |  | 408h | 19,016 |
| 15 | 1.2.1 | Demolición del espacio existente |  | 3d | 2015-04-27 | 2015-04-29 |  | 0.75d | 0d | empresa de demolición | 24h | 4,000 |
| 16 | 1.2.2 | Levantar tabiques |  | 4d | 2015-04-30 | 2015-05-05 | 15 | 0.75d | 0d | empresa constructora | 32h | 1,600 |
| 17 | 1.2.3 | Instalación eléctrica |  | 6d | 2015-05-06 | 2015-05-13 | 16 | 0.75d | 0d | electricista | 48h | 2,400 |
| 18 | 1.2.4 | Instalación de líneas de voz y datos |  | 3d | 2015-05-07 | 2015-05-11 | 17SS+1d | 2.75d | 2d | electricista | 24h | 1,200 |
| 19 | 1.2.5 | Terminar paredes |  | 2w | 2015-05-14 | 2015-05-27 | 17, 18 | 0.75d | 0d | pintor | 80h | 4,400 |
| 20 | 1.2.6 | Instalar puertas y ventanas |  | 3d | 2015-05-26 | 2015-05-28 | 19FS-2d | 4.75d | 4d | carpintero | 24h | 840 |
| 21 | 1.2.7 | Pintar |  | 4d | 2015-05-26 | 2015-05-29 | 19FS-2d | 0.75d | 0d | pintor | 32h | 1,280 |
| 22 | 1.2.8 | Colocar moqueta: oficinas |  | 3d | 2015-06-01 | 2015-06-03 | 21 | 0.75d | 0d | empresa revestimiento suelo | 24h |  |
| 23 | 1.2.9 | Colocar linóleo: sala del servidor |  | 3d | 2015-06-01 | 2015-06-03 | 22SS | 0.75d | 0d | empresa revestimiento suelo | 24h |  |
| 24 | 1.2.10 | Ultimas reparaciones |  | 1w | 2015-06-04 | 2015-06-10 | 20, 22, 23 | 0.75d | 0d | carpintero | 40h | 1,400 |
| 25 | 1.2.11 | Probar sistemas |  | 2d | 2015-06-11 | 2015-06-12 | 24 | 1.75d | 1d | electricista | 16h | 800 |
| 26 | 1.2.12 | Revisión de acabado |  | 3d | 2015-06-11 | 2015-06-15 | 24, 25FF | 0.75d | 0d | carpintero | 24h | 840 |
| 27 | 1.2.13 | Limpieza final |  | 2d | 2015-06-15 | 2015-06-17 | 26 | 0d |  | portero | 16h | 256 |
| 28 | 1.2.14 | Remodelación terminada | milestone | 0d | 2015-06-17 | 2015-06-17 | 27 | 0d |  |  |  |  |

| ID | WBS | Task | Type | Duration | Start | Finish | Predecessors | Total slack | Free slack | Resources | Work | Cost |
| --- | --- | --- | --- | --- | --- | --- | --- | --- | --- | --- | --- | --- |
| 29 | 1.3 | **Traslado** |  | 9.38d | 2015-06-18 | 2015-07-01 | 14 | 0d |  |  | 151h | 3,888 |
| 30 | 1.3.1 | **Oficinas** |  | 6.5d | 2015-06-18 | 2015-06-26 |  | 0d |  |  | 84h | 2,232 |
| 31 | 1.3.1.1 | Desconectar computadoras/equipos |  | 2d | 2015-06-18 | 2015-06-19 |  | 0d |  | técnico informático 1 | 16h | 528 |
| 32 | 1.3.1.2 | Desmontar mobiliario |  | 2d | 2015-06-19 | 2015-06-22 | 31FS-1d | 2.88d | 0d | ordenanza | 16h | 288 |
| 33 | 1.3.1.3 | Trasladar mobiliario/equipo/cajas |  | 4h | 2015-06-23 | 2015-06-23 | 32 | 2.88d | 0d | ordenanza | 4h | 72 |
| 34 | 1.3.1.4 | Montar mobiliario |  | 2d | 2015-06-23 | 2015-06-25 | 33 | 2.88d | 0d | ordenanza | 16h | 288 |
| 35 | 1.3.1.5 | Conectar computadoras/equipos |  | 2d | 2015-06-24 | 2015-06-26 | 34FS-1d | 2.88d | 0d | técnico informático 1 [200%] | 32h | 1,056 |
| 36 | 1.3.1.6 | Oficinas terminadas | milestone | 0d | 2015-06-26 | 2015-06-26 | 35 | 2.88d |  |  |  |  |
| 37 | 1.3.2 | **Sala del servidor** |  | 7.38d | 2015-06-22 | 2015-07-01 | 31 | 0d |  |  | 67h | 1,656 |
| 38 | 1.3.2.1 | Hacer copia de seguridad del servidor |  | 15h | 2015-06-22 | 2015-06-23 |  | 0d |  | servidor | 15h |  |
| 39 | 1.3.2.2 | Desconectar servidor |  | 2d | 2015-06-23 | 2015-06-25 | 38 | 0d |  | técnico informático 1 | 16h | 528 |
| 40 | 1.3.2.3 | Trasladar servidor |  | 4h | 2015-06-25 | 2015-06-26 | 39 | 0d |  | ordenanza | 4h | 72 |
| 41 | 1.3.2.4 | Conectar servidor |  | 2d | 2015-06-26 | 2015-06-30 | 40 | 0d |  | técnico informático 1 | 16h | 528 |
| 42 | 1.3.2.5 | Probar servidor |  | 1d | 2015-06-30 | 2015-07-01 | 41 | 0d |  | técnico informático 1 [200%] | 16h | 528 |
| 43 | 1.3.2.6 | Sala del servidor terminada | milestone | 0d | 2015-07-01 | 2015-07-01 | 42 | 0d |  |  |  |  |
| 44 | 1.4 | Traslado terminado | milestone | 0d | 2015-07-01 | 2015-07-01 | 29, 36 | 0d |  |  |  |  |
