# Proyecto de las oficinas centrales

Schedule from MS Project, 2015-07-28 to 2015-11-05, scheduled back from the finish, costs in $.
Reubicación

## Calendars

- Estándar: Mon-Fri 08:00-12:00, 13:00-17:00; Sat-Sun off.

## Resources

| Resource | Group | Rate |
| --- | --- | --- |
| auxiliar administrativo | personal oficina | 20 |
| arquitecto | contratado | 65 |
| ayudante del jefe de operaciones | personal oficina | 25 |
| carpintero | mantenimiento | 35 |
| responsable de finanzas | directiva | 38.46 |
| técnico informático 1 | técnicos | 33 |
| técnico informático 2 | técnicos | 26 |
| sala de conferencias | espacios |  |
| empresa de demolición | contratado |  |
| electricista | mantenimiento | 50 |
| empresa revestimiento suelo | contratado |  |
| empresa constructora | contratado | 50 |
| portero | mantenimiento | 16 |
| ordenanza | mantenimiento | 18 |
| jefe de oficina | directiva | 21.63 |
| jefe de operaciones | directiva | 25 |
| pintor | mantenimiento | 40 |
| presidente | directiva | 43.27 |
| agente inmobiliario | contratado | 50 |
| camión | contratado | 30 |
| vicepresidente | directiva | 36.06 |
| servidor |  |  |

## Schedule

| ID | WBS | Task | Type | Duration | Start | Finish | Predecessors | Total slack | Constraint | Resources | Work | Cost |
| --- | --- | --- | --- | --- | --- | --- | --- | --- | --- | --- | --- | --- |
| 1 | 1 | **Reubicación oficinas centrales** |  | 71.62d | 2015-07-28 | 2015-11-05 |  | 0d | as late as possible |  | 1223h | 51,734.38 |
| 2 | 1.1 | **Planificación** |  | 30d | 2015-07-28 | 2015-09-08 |  | 0d | as late as possible |  | 664h | 28,730.38 |
| 3 | 1.1.1 | Escribir propuesta |  | 3d | 2015-07-28 | 2015-07-31 |  | 0d |  | jefe de operaciones; jefe de oficina | 36h | 819.23 |
| 4 | 1.1.2 | Contratar arquitecto |  | 2d | 2015-07-29 | 2015-07-31 | 3FF | 0d |  | jefe de oficina; vicepresidente | 32h | 923.07 |
| 5 | 1.1.3 | Localizar nueva ubicación |  | 1w | 2015-07-31 | 2015-08-07 | 4 | 0d |  | arquitecto; jefe de oficina; agente inmobiliario | 120h | 5,465.38 |
| 6 | 1.1.4 | Presentar propuesta |  | 2d | 2015-08-07 | 2015-08-11 | 5 | 0d |  | jefe de operaciones; sala de conferencias; arquitecto | 48h | 1,440 |
| 7 | 1.1.5 | Aprobación de la directiva | milestone | 0d | 2015-08-11 | 2015-08-11 | 6 | 0d |  |  |  |  |
| 8 | 1.1.6 | Negociar nuevo alquiler |  | 4d | 2015-08-11 | 2015-08-17 | 7 | 0d |  | vicepresidente; responsable de finanzas; agente inmobiliario | 96h | 3,984.62 |
| 9 | 1.1.7 | Terminar dibujos |  | 1w | 2015-08-13 | 2015-08-20 | 8FS-2d | 0d |  | arquitecto [200%] | 80h | 5,200 |
| 10 | 1.1.8 | Seleccionar subcontratados |  | 1.5w | 2015-08-18 | 2015-08-28 | 9FS-2d | 0d |  | arquitecto; jefe de operaciones; jefe de oficina | 180h | 6,698.08 |
| 11 | 1.1.9 | Contratar empresa de mudanzas |  | 3d | 2015-08-25 | 2015-08-28 | 10FF | 0d |  | jefe de operaciones [50%] | 12h | 300 |
| 12 | 1.1.10 | Enviar dibujos |  | 1.5w | 2015-08-28 | 2015-09-08 | 11 | 0d |  | arquitecto | 60h | 3,900 |
| 13 | 1.1.11 | Permisos recibidos | milestone | 0d | 2015-09-08 | 2015-09-08 | 12 | 0d |  |  |  |  |
| 14 | 1.2 | **Remodelación** |  | 32.25d | 2015-09-08 | 2015-10-22 | 2 | 0d | as late as possible |  | 408h | 19,116 |
| 15 | 1.2.1 | Demolición del espacio existente |  | 3d | 2015-09-08 | 2015-09-11 |  | 0d |  | empresa de demolición | 24h | 4,000 |
| 16 | 1.2.2 | Levantar tabiques |  | 4d | 2015-09-11 | 2015-09-17 | 15 | 0d |  | empresa constructora | 32h | 1,600 |
| 17 | 1.2.3 | Instalación eléctrica |  | 6d | 2015-09-17 | 2015-09-25 | 16 | 0d |  | electricista | 48h | 2,400 |
| 18 | 1.2.4 | Instalación de líneas de voz y datos |  | 3d | 2015-09-18 | 2015-09-23 | 17SS+1d | 2d |  | electricista | 24h | 1,200 |
| 19 | 1.2.5 | Terminar paredes |  | 1w | 2015-09-25 | 2015-10-02 | 17, 18 | 0d |  | pintor; empresa constructora | 80h | 4,200 |
| 20 | 1.2.6 | Instalar puertas y ventanas |  | 3d | 2015-09-30 | 2015-10-05 | 19FS-2d | 4d |  | carpintero | 24h | 840 |
| 21 | 1.2.7 | Pintar |  | 4d | 2015-09-30 | 2015-10-06 | 19FS-2d | 0d |  | pintor | 32h | 1,280 |
| 22 | 1.2.8 | Colocar moqueta: oficinas |  | 3d | 2015-10-06 | 2015-10-09 | 21 | 0d |  | empresa revestimiento suelo | 24h |  |
| 23 | 1.2.9 | Colocar linóleo: sala del servidor |  | 3d | 2015-10-06 | 2015-10-09 | 22SS | 0d |  | empresa revestimiento suelo | 24h |  |
| 24 | 1.2.10 | Ultimas reparaciones |  | 1w | 2015-10-09 | 2015-10-16 | 20, 22, 23 | 0d |  | carpintero; electricista | 40h | 1,700 |
| 25 | 1.2.11 | Probar sistemas |  | 2d | 2015-10-16 | 2015-10-20 | 24 | 1d |  | electricista | 16h | 800 |
| 26 | 1.2.12 | Revisión de acabado |  | 3d | 2015-10-16 | 2015-10-21 | 24, 25FF | 0d |  | carpintero | 24h | 840 |
| 27 | 1.2.13 | Limpieza final |  | 2d | 2015-10-21 | 2015-10-22 | 26 | 0d |  | portero | 16h | 256 |
| 28 | 1.2.14 | Remodelación terminada | milestone | 0d | 2015-10-22 | 2015-10-22 | 27 | 0.62d |  |  |  |  |

| ID | WBS | Task | Type | Duration | Start | Finish | Predecessors | Total slack | Free slack | Constraint | Resources | Work | Cost |
| --- | --- | --- | --- | --- | --- | --- | --- | --- | --- | --- | --- | --- | --- |
| 29 | 1.3 | **Traslado** |  | 9.38d | 2015-10-23 | 2015-11-05 | 14 | 0d |  | as late as possible |  | 151h | 3,888 |
| 30 | 1.3.1 | **Oficinas** |  | 6.5d | 2015-10-23 | 2015-11-02 |  | 0d |  | as late as possible |  | 84h | 2,232 |
| 31 | 1.3.1.1 | Desconectar computadoras/equipos |  | 2d | 2015-10-23 | 2015-10-26 |  | 0.62d | 0d |  | técnico informático 1 | 16h | 528 |
| 32 | 1.3.1.2 | Desmontar mobiliario |  | 2d | 2015-10-26 | 2015-10-27 | 31FS-1d | 3.5d | 0d |  | ordenanza | 16h | 288 |
| 33 | 1.3.1.3 | Trasladar mobiliario/equipo/cajas |  | 4h | 2015-10-28 | 2015-10-28 | 32 | 3.5d | 0d |  | ordenanza | 4h | 72 |
| 34 | 1.3.1.4 | Montar mobiliario |  | 2d | 2015-10-28 | 2015-10-30 | 33 | 3.5d | 0d |  | ordenanza | 16h | 288 |
| 35 | 1.3.1.5 | Conectar computadoras/equipos |  | 2d | 2015-10-29 | 2015-11-02 | 34FS-1d | 3.5d | 0d |  | técnico informático 1 [200%] | 32h | 1,056 |
| 36 | 1.3.1.6 | Oficinas terminadas | milestone | 0d | 2015-11-02 | 2015-11-02 | 35 | 3.5d | 2.88d |  |  |  |  |
| 37 | 1.3.2 | **Sala del servidor** |  | 7.38d | 2015-10-27 | 2015-11-05 | 31 | 0d |  | as late as possible |  | 67h | 1,656 |
| 38 | 1.3.2.1 | Hacer copia de seguridad del servidor |  | 15h | 2015-10-27 | 2015-10-28 |  | 0.62d | 0d |  | servidor | 15h |  |
| 39 | 1.3.2.2 | Desconectar servidor |  | 2d | 2015-10-28 | 2015-10-30 | 38 | 0.62d | 0d |  | técnico informático 1 | 16h | 528 |
| 40 | 1.3.2.3 | Trasladar servidor |  | 4h | 2015-10-30 | 2015-11-02 | 39 | 0.62d | 0d |  | ordenanza | 4h | 72 |
| 41 | 1.3.2.4 | Conectar servidor |  | 2d | 2015-11-02 | 2015-11-04 | 40 | 0.62d | 0d |  | técnico informático 1 | 16h | 528 |
| 42 | 1.3.2.5 | Probar servidor |  | 1d | 2015-11-04 | 2015-11-05 | 41 | 0.62d | 0d |  | técnico informático 1 [200%] | 16h | 528 |
| 43 | 1.3.2.6 | Sala del servidor terminada | milestone | 0d | 2015-11-05 | 2015-11-05 | 42 | 0.62d |  |  |  |  |  |
| 44 | 1.4 | Traslado terminado | milestone | 0d | 2015-11-05 | 2015-11-05 | 29, 36 | 0.62d |  |  |  |  |  |
