# Reunión de accionistas

Schedule from MS Project, 2015-07-07 to 2015-08-21, costs in $.
Informe anual de 1999

## Calendars

- Estándar: Mon-Fri 08:00-12:00, 13:00-17:00; Sat-Sun off.

## Resources

| Resource | Group | Rate |
| --- | --- | --- |
| secretario | personal oficina | 11 |
| vicepresidente | directiva | 36.06 |
| jefe de oficina | directiva | 21.63 |
| auxiliar administrativo | personal oficina | 20 |

## Schedule

| ID | WBS | Task | Type | Duration | Start | Finish | Predecessors | Total slack | Free slack | Resources | Work | Cost |
| --- | --- | --- | --- | --- | --- | --- | --- | --- | --- | --- | --- | --- |
| 1 | 1 | **Reunión de accionistas** |  | 33.5d | 2015-07-07 | 2015-08-21 |  | 0d |  |  | 257h | 5,383.61 |
| 2 | 1.1 | **Planificación preliminar** |  | 10.5d | 2015-07-07 | 2015-07-21 |  | 0d |  |  | 88h | 2,010.3 |
| 3 | 1.1.1 | Programar fecha de la conferencia |  | 2d | 2015-07-07 | 2015-07-10 |  | 0d |  | vicepresidente; jefe de oficina | 32h | 923.07 |
| 4 | 1.1.2 | Reservar centro de conferencias |  | 1d | 2015-07-13 | 2015-07-14 | 3 | 0d |  | secretario | 8h | 88 |
| 5 | 1.1.3 | Buscar conferenciante |  | 3d | 2015-07-14 | 2015-07-21 | 4FS-0.5d | 0d |  | jefe de oficina; auxiliar administrativo | 48h | 999.23 |
| 6 | 1.1.4 | Planificación preliminar completa | milestone | 0d | 2015-07-21 | 2015-07-21 | 5 | 0.5d |  |  |  |  |
| 7 | 1.2 | **Carta de notificación** |  | 9d | 2015-07-22 | 2015-08-03 | 2 | 0d |  |  | 57h | 1,270.08 |
| 8 | 1.2.1 | Ordenar lista de envío |  | 1h | 2015-07-22 | 2015-07-22 |  | 0d |  | secretario | 1h | 11 |
| 9 | 1.2.2 | Preparar carta |  | 1d | 2015-07-22 | 2015-07-23 | 8SS | 0d |  | auxiliar administrativo; jefe de oficina | 16h | 333.08 |
| 10 | 1.2.3 | Revisar carta |  | 1d | 2015-07-24 | 2015-07-27 | 9 | 0d |  | jefe de oficina; vicepresidente | 16h | 461.54 |
| 11 | 1.2.4 | Aprobar carta |  | 1d | 2015-07-27 | 2015-07-28 | 10FS-0.5d | 0d |  | vicepresidente | 8h | 288.46 |
| 12 | 1.2.5 | Imprimir carta |  | 2d | 2015-07-29 | 2015-08-03 | 11 | 1.5d | 0d | secretario | 16h | 176 |
| 13 | 1.2.6 | Enviar carta | milestone | 0d | 2015-08-03 | 2015-08-03 | 12 | 2d |  |  |  |  |
| 14 | 1.3 | **Detalles de la reunión** |  | 15.5d | 2015-07-29 | 2015-08-19 | 2, 11 | 0d |  |  | 112h | 2,103.23 |
| 15 | 1.3.1 | Preparar menú con empresa catering |  | 3d | 2015-07-29 | 2015-08-05 |  | 0d |  | auxiliar administrativo; jefe de oficina | 48h | 999.23 |
| 16 | 1.3.2 | Preparar salas de reunión del comité |  | 1d | 2015-08-06 | 2015-08-07 | 13, 15 | 0d |  | secretario; auxiliar administrativo | 16h | 248 |
| 17 | 1.3.3 | Preparar equipamiento necesario |  | 1d | 2015-08-06 | 2015-08-07 | 16FF | 0d |  | auxiliar administrativo; secretario | 16h | 288 |
| 18 | 1.3.4 | Preparar programa |  | 3d | 2015-08-10 | 2015-08-17 | 17 | 0d |  | auxiliar administrativo | 24h | 480 |
| 19 | 1.3.5 | Imprimir programa |  | 1d | 2015-08-18 | 2015-08-19 | 18 | 0d |  | secretario | 8h | 88 |
| 20 | 1.4 | Celebración de la reunión | milestone | 0d | 2015-08-21 | 2015-08-21 | 14FS+2d | 0d |  |  |  |  |
